# MS_Project_SAE

Schedule from MS Project, 2024-09-09 to 2025-03-25, status date 2024-12-10, 1.5 hours a day, costs in €, A marks actual dates.

## Calendars

- SAE: Mon off; Tue 08:00-10:00; Wed-Sun off. Exceptions (off unless hours are given): 2024-09-09 10:00-12:00 (SAE 09/09/24), 2024-09-10 08:00-10:00, 15:30-17:30 (SAE 10/09/24), 2024-09-12 08:00-10:00 (TP Analyse), 2024-09-20 08:00-10:00 (TP Analyse), 2024-09-23 10:00-12:00, 15:30-17:30 (SAE 23/09/24), 2024-09-30 13:30-15:30 (SAE 30/09/24), 2024-10-09 15:30-17:30 (SAE 09/10/24), 2024-10-10 09:00-12:00 (TP PHP), 2024-10-14 15:30-17:30 (SAE 14/10/24), 2024-10-16 11:00-12:00 (Principe SOLID), 2024-10-18 15:30-17:30 (TP PHP), 2024-10-21 10:00-12:00 (TP PHP), 2024-10-23 11:00-12:00 (Principe SOLID), 2024-10-24 08:00-10:00 (SAE 24/10/24), 2024-10-25 13:30-15:30 (SAE 25/10/24), 2024-10-28 to 2024-11-03 (Vacances toussaints), 2024-11-04 08:00-10:00 (SAE 04/11/24), 2024-11-06 15:30-17:30 (SAE 06/11/24), 2024-11-07 09:00-10:00, 13:30-15:30 (SAE 07/11/24 / Principe SOLID), 2024-11-11 (Armistice), 2024-11-14 09:00-10:00 (Principe SOLID), 2024-11-20 15:30-17:30 (SAE 20/11/24), 2024-11-22 13:30-15:30 (SAE 22/11/24), 2024-11-25 08:00-10:00 (SAE 25/11/24), 2024-11-27 08:00-10:00 (SAE 27/11/24), 2024-11-29 10:00-12:00 (SAE 29/11/24), 2024-12-02 08:00-12:00 (SAE 02/12/24), 2024-12-03 08:00-10:00, 13:30-15:30 (SAE 03/12/24), 2024-12-06 10:00-12:00 (SAE 06/12/24), 2024-12-09 08:00-10:00 (SAE 09/12/24), 2024-12-10 08:00-10:00, 13:30-17:30 (SAE 10/12/24), 2024-12-13 10:00-12:00 (SAE 13/12/24), 2024-12-16 08:00-12:00 (SAE 16/12/24), 2024-12-17 08:00-10:00, 13:30-15:30 (SAE 17/12/24), 2024-12-19 08:00-12:00, 13:30-15:30 (SAE 19/12/24), 2024-12-21 to 2025-01-05 (Vacances Noël), 2025-01-06 08:00-12:00 (SAE 06/01/25), 2025-01-09 08:00-12:00 (SAE 09/01/25), 2025-01-10 08:00-12:00, 13:30-15:30 (SAE 10/01/25), 2025-01-13 08:00-10:00 (SAE 13/01/25), 2025-01-14 08:00-12:00, 15:30-17:30 (SAE 14/01/25), 2025-01-15 13:30-15:30 (SAE 15/01/25), 2025-01-16 08:00-12:00, 13:30-15:30 (SAE 16/01/25), 2025-01-21 08:00-12:00 (S4), 2025-01-28 08:00-12:00 (S5), 2025-02-04 08:00-12:00 (S6), 2025-02-05 10:00-12:00 (TP Web API), 2025-02-11 08:00-12:00 (S7), 2025-02-12 10:00-12:00 (TP Entity Framework), 2025-02-18 08:00-12:00 (S8), 2025-02-19 10:00-12:00 (TP Web API), 2025-02-24 to 2025-03-02 (Vacances Février), 2025-03-04 08:00-12:00 (S10), 2025-03-05 10:00-12:00 (TP Entity Framework), 2025-03-11 08:00-12:00 (S11), 2025-03-12 10:00-12:00 (TP Web API), 2025-03-18 08:00-12:00 (S12), 2025-03-19 09:00-12:00, 14:00-18:00 (TP Entity Framework), 2025-03-25 08:00-12:00 (S13).

## Resources

| Resource | Rate |
| --- | --- |
| Kévin | 40 |
| Kentin | 40 |
| Maxime | 40 |
| Léni | 40 |
| Tommy | 40 |
| Louis | 40 |

## Schedule

| ID | WBS | Task | Duration | Start | Finish | Predecessors | Complete | Remaining | Baseline start | Baseline finish | Baseline duration | Total slack | Constraint | Deadline | Resources | Work | Actual work | Cost | Baseline cost | Actual cost |
| --- | --- | --- | --- | --- | --- | --- | --- | --- | --- | --- | --- | --- | --- | --- | --- | --- | --- | --- | --- | --- |
| 1 | 1 | **WikiFantasy** | 124.08d | 2024-09-09 A | 2025-03-25 |  | 89% | 13.98d | 2024-09-09 | 2025-03-19 | 93.53d | 0d |  |  |  | 615.87h | 530.55h | 24,634.7 | 20,960 | 21,222.03 |
| 2 | 1.1 | **Analyse** | 7.56d | 2024-09-09 A | 2024-09-20 A |  | 100% |  | 2024-09-09 | 2024-09-19 | 7.83d |  | finish no later than 2024-12-22 | 2024-09-22 |  | 47h | 47h | 1,880.02 | 1,520 | 1,880.02 |
| 3 | 1.1.1 | Contexte | 4h | 2024-09-09 A | 2024-09-10 A |  | 100% |  | 2024-09-09 | 2024-09-09 | 1.5h |  |  |  | Louis; Tommy | 8h | 8h | 320 | 120 | 320 |
| 4 | 1.1.2 | Personas | 2.75h | 2024-09-11 A | 2024-09-17 A | 3 | 100% |  | 2024-09-11 | 2024-09-11 | 1.42h |  |  |  | Louis; Tommy | 4h | 4h | 160 | 80 | 160 |
| 5 | 1.1.3 | User stories | 4h | 2024-09-11 A | 2024-09-20 A | 4, 3 | 100% |  | 2024-09-11 | 2024-09-16 | 2h |  |  |  | Louis; Tommy | 4h | 4h | 160 | 80 | 160 |
| 6 | 1.1.4 | Use case | 3.64h | 2024-09-11 A | 2024-09-20 A | 3 | 100% |  | 2024-09-11 | 2024-09-17 | 3h |  |  |  | Louis; Tommy | 4h | 4h | 160.02 | 120 | 160.02 |
| 7 | 1.1.5 | Sketch | 4.58h | 2024-09-10 A | 2024-09-17 A | 3 | 100% |  | 2024-09-10 | 2024-09-11 | 2.25h |  |  |  | Kentin; Louis | 8h | 8h | 320 | 240 | 320 |
| 8 | 1.1.6 | Maquette | 2.5h | 2024-09-11 A | 2024-09-17 A | 7, 3 | 100% |  | 2024-09-11 | 2024-09-16 | 3h |  |  |  | Kentin; Kévin; Léni; Maxime | 10h | 10h | 400 | 480 | 400 |
| 9 | 1.1.7 | Storyboard | 4h | 2024-09-16 A | 2024-09-19 A | 8, 3 | 100% |  | 2024-09-16 | 2024-09-19 | 5h |  |  |  | Kentin; Kévin | 4h | 4h | 160 | 200 | 160 |
| 10 | 1.1.8 | Diagramme de flux | 3h | 2024-09-11 A | 2024-09-20 A | 7, 3 | 100% |  | 2024-09-11 | 2024-09-18 | 3.33h |  |  |  | Kentin; Kévin; Léni; Maxime | 5h | 5h | 200 | 200 | 200 |
| 11 | 1.2 | **Base de données** | 31.15d | 2024-09-19 A | 2024-11-14 A | 2 | 100% |  | 2024-09-19 | 2024-11-14 | 26.39d |  | finish no later than 2024-11-17 | 2024-11-17 |  | 47h | 47h | 1,880 | 480 | 1,880 |
| 12 | 1.2.1 | MCD | 4.28h | 2024-09-19 A | 2024-10-01 A |  | 100% |  | 2024-09-19 | 2024-09-24 | 2h |  |  |  | Louis; Tommy | 8h | 8h | 320 | 160 | 320 |
| 13 | 1.2.2 | MLD | 5h | 2024-10-07 A | 2024-10-10 A |  | 100% |  | 2024-10-07 | 2024-10-07 | 1h |  |  |  | Louis; Tommy | 10h | 10h | 400 | 80 | 400 |
| 14 | 1.2.3 | Initialisation BDD | 7.17h | 2024-10-07 A | 2024-10-22 A | 12, 13 | 100% |  | 2024-10-07 | 2024-10-21 | 1h |  |  |  | Louis; Maxime; Tommy; Léni | 14h | 14h | 560 | 80 | 560 |
| 15 | 1.2.4 | Création du jeu de données | 8.08h | 2024-10-23 A | 2024-11-07 A | 14 | 100% |  | 2024-10-23 | 2024-11-06 | 1.89h |  |  |  | Kévin; Léni; Louis; Tommy | 14h | 14h | 560 | 120 | 560 |
| 16 | 1.2.5 | Deployer BDD | 1h | 2024-11-13 A | 2024-11-14 A | 15 | 100% |  | 2024-11-13 | 2024-11-14 | 0.61h |  |  |  | Maxime | 1h | 1h | 40 | 40 | 40 |
| 17 | 1.3 | **Application WEB** | 33.56d | 2024-09-19 A | 2024-11-20 | 2 | 96% | 1.41d | 2024-09-19 | 2024-11-13 | 25.34d | 0d | finish no later than 2024-11-21 | 2024-11-21 |  | 174.99h | 166.92h | 6,999.71 | 7,040 | 6,676.74 |
| 18 | 1.3.1 | **Solidification** | 2.89d | 2024-11-14 A | 2024-11-20 A | 20, 24 | 100% |  |  |  |  |  |  |  |  | 10h | 10h | 400 |  | 400 |
| 19 | 1.3.1.1 | Conception SOLID | 4.33h | 2024-11-14 A | 2024-11-20 A |  | 100% |  |  |  |  |  |  |  | Kentin; Léni; Tommy | 10h | 10h | 400 |  | 400 |
| 20 | 1.3.2 | **PHP** | 8.27d | 2024-09-19 A | 2024-10-08 A | 2 | 100% |  | 2024-09-19 | 2024-10-21 | 16.67d |  |  | 2024-11-21 |  | 80h | 80h | 3,199.84 | 3,840 | 3,199.84 |
| 21 | 1.3.2.1 | Gateway | 7.37h | 2024-09-30 A | 2024-10-03 A | 9 | 100% |  | 2024-09-30 | 2024-10-21 | 11.18h |  |  |  | Kévin; Léni; Louis; Maxime; Tommy; Kentin | 20h | 20h | 799.96 | 960 | 799.96 |
| 22 | 1.3.2.2 | Model | 4.11h | 2024-09-24 A | 2024-10-08 A |  | 100% |  | 2024-09-24 | 2024-10-15 | 18.15h |  |  |  | Kévin; Léni; Louis; Tommy; Maxime; Kentin | 30h | 30h | 1,199.95 | 1,280 | 1,199.95 |
| 23 | 1.3.2.3 | Controller | 11.08h | 2024-09-19 A | 2024-10-08 A |  | 100% |  | 2024-09-19 | 2024-10-10 | 17.28h |  |  |  | Kévin; Léni; Louis; Maxime; Tommy; Kentin | 30h | 30h | 1,199.93 | 1,600 | 1,199.93 |
| 24 | 1.3.3 | **Vues** | 30.67d | 2024-09-19 A | 2024-11-13 A |  | 100% |  | 2024-09-19 | 2024-11-13 | 25.34d |  |  | 2024-11-21 |  | 69h | 69h | 2,760 | 2,240 | 2,760 |
| 25 | 1.3.3.1 | Bandeau | 10.48h | 2024-09-19 A | 2024-10-10 A |  | 100% |  | 2024-09-19 | 2024-09-24 | 3h |  |  |  | Kentin; Maxime | 14h | 14h | 560 | 240 | 560 |
| 26 | 1.3.3.2 | Accueil | 3.86h | 2024-11-05 A | 2024-11-12 A | 25 | 100% |  | 2024-11-05 | 2024-11-12 | 3.86h |  |  |  | Kentin; Maxime | 6h | 6h | 240 | 240 | 240 |
| 27 | 1.3.3.3 | Profil | 18h | 2024-10-09 A | 2024-11-04 A | 25 | 100% |  | 2024-10-09 | 2024-10-23 | 12h |  |  |  | Léni | 18h | 18h | 720 | 480 | 720 |
| 28 | 1.3.3.4 | Login/Signup | 14h | 2024-10-08 A | 2024-11-12 A | 25 | 100% |  | 2024-10-08 | 2024-10-22 | 7.5h |  |  |  | Kévin; Léni; Louis; Maxime | 14h | 14h | 560 | 400 | 560 |
| 29 | 1.3.3.5 | Citation | 4h | 2024-11-05 A | 2024-11-12 A | 25 | 100% |  | 2024-11-05 | 2024-11-12 | 4h |  |  |  | Kévin; Maxime | 4h | 4h | 160 | 160 | 160 |
| 30 | 1.3.3.6 | Recherche | 3.79h | 2024-10-24 A | 2024-11-05 A | 25 | 100% |  | 2024-10-24 | 2024-11-05 | 4.46h |  |  |  | Kentin; Maxime | 5h | 5h | 200 | 240 | 200 |
| 31 | 1.3.3.7 | Quiz | 3h | 2024-10-08 A | 2024-10-10 A | 25 | 100% |  | 2024-10-08 | 2024-10-14 | 5h |  |  |  | Louis; Tommy | 6h | 6h | 240 | 400 | 240 |
| 32 | 1.3.3.8 | Favoris | 2h | 2024-11-07 A | 2024-11-13 A | 25 | 100% |  | 2024-11-07 | 2024-11-13 | 2h |  |  |  | Maxime | 2h | 2h | 80 | 80 | 80 |

| ID | WBS | Task | Duration | Start | Finish | Predecessors | Complete | Remaining | Baseline start | Baseline finish | Baseline duration | Total slack | Free slack | Constraint | Deadline | Resources | Work | Actual work | Cost | Baseline cost | Actual cost |
| --- | --- | --- | --- | --- | --- | --- | --- | --- | --- | --- | --- | --- | --- | --- | --- | --- | --- | --- | --- | --- | --- |
| 33 | 1.3.4 | **Test et deploiement** | 18d | 2024-10-08 A | 2024-11-06 | 20 | 50% | 9d | 2024-10-21 | 2024-11-06 | 5.91d | 7.28d |  | finish no later than 2024-11-21 | 2024-11-21 |  | 16h | 7.92h | 639.87 | 960 | 316.89 |
| 34 | 1.3.4.1 | Tests | 6.62h | 2024-10-08 A | 2024-10-18 |  | 50% | 3.31h | 2024-10-21 | 2024-11-05 | 6.91h | 8.71d | 8.29d |  |  | Kentin; Kévin; Léni; Louis; Maxime; Tommy | 12h | 5.79h | 479.87 | 800 | 231.73 |
| 35 | 1.3.4.2 | Deploiement | 1.25h | 2024-11-05 A | 2024-11-06 | 34 | 50% | 0.62h | 2024-11-05 | 2024-11-06 | 1.77h | 7.28d |  |  |  | Kentin; Kévin; Léni; Louis; Maxime; Tommy | 4h | 2.13h | 160 | 160 | 85.16 |
| 36 | 1.4 | **Application web administrateur** | 45.9d | 2024-11-20 A | 2025-01-15 | 17, 2 | 92% | 3.48d | 2024-11-13 | 2025-01-06 | 22.72d | 0d |  |  | 2025-01-19 |  | 116h | 108.87h | 4,640.01 | 3,720 | 4,354.66 |
| 37 | 1.4.1 | **Web admin** | 45.9d | 2024-11-20 A | 2025-01-15 |  | 92% | 3.48d | 2024-11-13 | 2025-01-06 | 22.72d | 0d |  |  |  |  | 116h | 108.87h | 4,640.01 | 3,720 | 4,354.66 |
| 38 | 1.4.1.1 | Diagramme UML | 9.28h | 2024-11-20 A | 2024-11-29 A |  | 100% |  | 2024-11-13 | 2024-11-20 | 6.96h |  |  |  |  | Kentin; Kévin; Léni; Louis; Maxime; Tommy | 20h | 20h | 800 | 600 | 800 |
| 39 | 1.4.1.2 | Faire le frontend | 47.68h | 2024-11-29 A | 2025-01-10 A | 38 | 100% |  | 2024-11-20 | 2024-12-05 | 13.14h |  |  |  |  | Kentin; Kévin [50%]; Léni; Louis; Maxime; Tommy | 36h | 36h | 1,440 | 1,120 | 1,440 |
| 40 | 1.4.1.3 | Faire le backend | 25.16h | 2024-11-29 A | 2024-12-16 A | 38 | 100% |  | 2024-11-25 | 2024-12-10 | 13.24h |  |  |  |  | Kentin; Kévin [50%]; Léni; Louis; Maxime; Tommy | 36h | 36h | 1,440.01 | 1,120 | 1,440.01 |
| 41 | 1.4.1.4 | Tester le code | 11.89h | 2025-01-10 A | 2025-01-15 | 38, 39, 40 | 40% | 7.13h | 2024-12-10 | 2025-01-06 | 10.9h | 0d |  |  |  | Kentin; Kévin; Léni; Louis; Maxime; Tommy | 24h | 16.87h | 960 | 880 | 674.65 |
| 42 | 1.5 | **Application mobile** | 25.95d | 2025-01-15 A | 2025-03-05 | 2, 36 | 66% | 8.74d | 2025-01-06 | 2025-03-04 | 28.41d | 0d |  | finish no later than 2025-04-04 | 2025-04-04 |  | 122.88h | 101.07h | 4,914.96 | 4,880 | 4,042.62 |
| 43 | 1.5.1 | Faire le diagramme UML | 5h | 2025-01-15 A | 2025-01-16 A |  | 100% |  | 2025-01-06 | 2025-01-09 | 4h |  |  |  |  | Kentin; Kévin; Léni; Louis; Maxime; Tommy | 30h | 30h | 1,200 | 960 | 1,200 |
| 44 | 1.5.2 | Faire des vues | 9.7h | 2025-01-16 A | 2025-01-28 | 43 | 79% | 2.03h | 2025-01-15 | 2025-02-11 | 13.56h | 9.09d | 6.72d |  |  | Kentin; Kévin; Léni; Louis; Maxime; Tommy | 26h | 23.97h | 1,040 | 960 | 958.86 |
| 45 | 1.5.3 | Faire le backend | 17.32h | 2025-01-16 A | 2025-02-11 | 43 | 80% | 3.46h | 2025-01-09 | 2025-02-10 | 24.75h | 2.38d | 0d |  |  | Kentin; Kévin; Léni; Louis; Maxime; Tommy | 35h | 31.42h | 1,399.93 | 2,000 | 1,256.65 |
| 46 | 1.5.4 | Tester le code | 11.89h | 2025-02-11 A | 2025-03-04 | 44, 45 | 30% | 8.32h | 2025-02-11 | 2025-03-04 | 10.9h | 0d |  |  |  | Kentin; Kévin; Léni; Louis; Maxime; Tommy | 24h | 15.68h | 960 | 880 | 627.11 |
| 47 | 1.5.5 | Déployer l'application | 1.45h | 2025-03-04 | 2025-03-05 | 46 |  |  | 2025-03-04 | 2025-03-04 | 0.36h | 0d |  |  |  | Kentin; Kévin; Léni; Louis; Maxime; Tommy | 7.88h |  | 315.03 | 80 |  |
| 48 | 1.6 | **API** | 12d | 2025-03-05 A | 2025-03-25 | 11, 2, 17, 36, 42 | 55% | 5.37d | 2025-03-04 | 2025-03-19 | 9.22d | 0d |  |  | 2025-04-04 |  | 108h | 59.7h | 4,320 | 3,320 | 2,388 |
| 49 | 1.6.1 | Faire le diagramme UML | 5.33h | 2025-03-05 A | 2025-03-12 A |  | 100% |  | 2025-03-04 | 2025-03-06 | 4h |  |  |  |  | Kentin; Kévin; Léni; Louis; Maxime; Tommy | 32h | 32h | 1,280 | 960 | 1,280 |
| 50 | 1.6.2 | Faire des routes | 4.33h | 2025-03-12 A | 2025-03-18 | 49 | 45% | 2.38h | 2025-03-12 | 2025-03-13 | 2h | 3.11d | 2.44d |  |  | Kentin; Kévin; Léni; Louis; Maxime; Tommy | 26h | 11.7h | 1,040 | 480 | 468 |
| 51 | 1.6.3 | Faire des requêtes à la BDD | 3.67h | 2025-03-18 A | 2025-03-19 | 49 | 40% | 2.2h | 2025-03-06 | 2025-03-12 | 3.33h | 0.67d | 0d |  |  | Louis; Maxime; Tommy; Kentin; Kévin; Léni | 22h | 8.8h | 880 | 800 | 352 |
| 52 | 1.6.4 | Mettre en place un ORM | 3.33h | 2025-03-19 A | 2025-03-19 | 50, 51 | 30% | 2.33h | 2025-03-13 | 2025-03-18 | 2.5h | 0.13d | 0d |  |  | Kentin; Kévin; Léni; Louis; Maxime; Tommy | 20h | 6h | 800 | 600 | 240 |
| 53 | 1.6.5 | Tester le code | 1.33h | 2025-03-19 A | 2025-03-25 | 52 | 15% | 1.13h | 2025-03-18 | 2025-03-19 | 2h | 0d |  |  |  | Kentin; Kévin; Léni; Louis; Maxime; Tommy | 8h | 1.2h | 320 | 480 | 48 |
